# OpenStreetPhoto

Schedule from GanttProject, 2008-11-24 to 2009-04-10.
Stichting OpenStreetPhoto

## Calendars

- Project calendar: Mon-Fri working; Sat-Sun off.

## Resources

| Resource |
| --- |
| Stefan |
| Rob |
| Lennart |
| Notaris |
| Milo |
| Roeland |

## Schedule

| ID | WBS | Task | Duration | Start | Finish | Predecessors | Resources |
| --- | --- | --- | --- | --- | --- | --- | --- |
| 1 | 1 | **Fase 1** | 0d | 2008-11-24 | 2008-11-24 |  |  |
| 2 | 1.1 | **Administratief** | 20d | 2008-11-24 | 2008-12-19 |  |  |
| 3 | 1.1.1 | **Oprichting** | 20d | 2008-11-24 | 2008-12-19 |  |  |
| 4 | 1.1.1.1 | **Stichting** | 17d | 2008-11-24 | 2008-12-16 |  |  |
| 5 | 1.1.1.1.1 | Statuten | 2d | 2008-11-24 | 2008-11-25 |  | Rob; Stefan |
| 6 | 1.1.1.1.2 | Notaris | 14d | 2008-11-26 | 2008-12-15 | 5 | Stefan |
| 7 | 1.1.1.1.3 | Inschrijven KVK | 1d | 2008-12-16 | 2008-12-16 | 6 | Notaris |
| 8 | 1.1.1.1.4 | Inschrijven Belastingdienst | 1d | 2008-12-16 | 2008-12-16 | 6 | Rob |
| 9 | 1.1.1.2 | Luchtfotografie vergunning | 1d | 2008-12-17 | 2008-12-17 | 4 | Stefan |
| 10 | 1.1.1.3 | Betaalrekening | 1d | 2008-12-17 | 2008-12-17 | 4 | Rob |
| 11 | 1.1.1.4 | Verzekering | 1d | 2008-12-19 | 2008-12-19 | 12 | Stefan |
| 12 | 1.2 | Digitale Pioniers gelden | 1d | 2008-12-18 | 2008-12-18 | 10 |  |
| 13 | 1.3 | **Ontwikkeling** | 15d | 2008-12-22 | 2009-01-09 |  |  |
| 14 | 1.3.1 | **Hardware** | 15d | 2008-12-22 | 2009-01-09 |  |  |
| 15 | 1.3.1.1 | Prototype 1 | 15d | 2008-12-22 | 2009-01-09 | 11, 12 | Rob |
| 16 | 2 | **Fase 2** | 7d | 2009-01-12 | 2009-01-20 | 1 |  |
| 17 | 2.1 | **Testen** | 3d | 2009-01-12 | 2009-01-14 |  |  |
| 18 | 2.1.1 | Vliegen op basis van GPS waypoints | 3d | 2009-01-12 | 2009-01-14 | 15 | Rob |
| 19 | 2.2 | **Software** | 7d | 2009-01-12 | 2009-01-20 |  |  |
| 20 | 2.2.1 | Orthophoto | 7d | 2009-01-12 | 2009-01-20 | 15 | Stefan |
| 21 | 3 | **Fase 3** | 14d | 2009-01-21 | 2009-02-09 | 16 |  |
| 22 | 3.1 | **Testen** | 7d | 2009-01-21 | 2009-01-29 |  |  |
| 23 | 3.1.1 | Foto's vanuit stilhangende positie | 7d | 2009-01-15 | 2009-01-23 | 18 | Rob |
| 24 | 3.2 | **Software** | 14d | 2009-01-21 | 2009-02-09 |  |  |
| 25 | 3.2.1 | GeoSIFT | 14d | 2009-01-12 | 2009-01-29 | 1 | Stefan; Roeland |

Notes:
- 10: ING starters rekening lijkt het goedkoopste.
- 15: Inkoop goederen in elkaar zetten van eerste Quadcopter
- 18: Het testen van waypoint vliegen. Eerste veiligheids testen, gecontroleerd uit de lucht vallen.
- 20: http://52north.org/index.php?option=com_projects&task=showProject&id=30&Itemid=127 / http://en.wikipedia.org/wiki/Orthophoto
- 23: Op een grid vliegen, en per punt een foto maken.
- 25: Bundler uitbreiden met GPS zoekruimte reductie. / http://phototour.cs.washington.edu/bundler

| ID | WBS | Task | Duration | Start | Finish | Predecessors | Resources |
| --- | --- | --- | --- | --- | --- | --- | --- |
| 26 | 3.3 | **Sales** | 2d | 2009-01-21 | 2009-01-22 | 20 |  |
| 27 | 3.3.1 | Gemeente benaderen | 1d | 2009-01-26 | 2009-01-26 | 23 | Stefan |
| 28 | 3.3.2 | KLPD benaderen | 1d | 2009-01-27 | 2009-01-27 | 27 | Stefan |
| 29 | 4 | **Fase 4** | 7d | 2009-02-10 | 2009-02-18 | 21 |  |
| 30 | 4.1 | **Testen** | 7d | 2009-02-10 | 2009-02-18 |  |  |
| 31 | 4.1.1 | Foto's vanuit vliegende positie | 7d | 2009-01-26 | 2009-02-03 | 1, 23 | Rob |
| 32 | 5 | **Fase 5** | 9d | 2009-02-19 | 2009-03-03 | 29 |  |
| 33 | 5.1 | **Sales** | 9d | 2009-02-19 | 2009-03-03 |  |  |
| 34 | 5.1.1 | Spielerij | 1d | 2009-02-04 | 2009-02-04 | 31 | Rob |
| 35 | 5.1.2 | Benaderen van media | 1d | 2009-03-03 | 2009-03-03 | 36, 39 |  |
| 36 | 5.1.3 | Benaderen gemeentes | 1d | 2009-03-02 | 2009-03-02 | 39 |  |
| 37 | 5.2 | **Software** | 7d | 2009-02-19 | 2009-02-27 |  |  |
| 38 | 5.2.1 | Integreren van WMS server | 7d | 2009-01-26 | 2009-02-03 | 20, 23 | Milo |
| 39 | 5.2.2 | Opleuken productie website | 7d | 2009-02-19 | 2009-02-27 | 20, 29 | Rob; Stefan |
| 40 | 6 | **Fase Productie** | 28d | 2009-03-04 | 2009-04-10 | 32 |  |
| 41 | 6.1 | **Sales** | 28d | 2009-03-04 | 2009-04-10 |  |  |
| 42 | 6.1.1 | Productie | 28d | 2009-02-04 | 2009-03-13 | 38 | Rob [20%]; Lennart [40%]; Stefan [20%] |
| 43 | 6.2 | **Ontwikkeling** | 28d | 2009-03-04 | 2009-04-10 |  |  |
| 44 | 6.2.1 | Nieuwe quadcopters | 28d | 2009-03-02 | 2009-04-08 | 1, 39 | Rob [80%]; Stefan [20%] |

Notes:
- 27: Gemeentes waarmee we eerder contact hebben gehad een eerste blik laten werpen op onze productie.
- 28: Aanbieden van quadcopters als low-cost ongevallen analyse.
- 34: Als foto's vanuit vliegende positie kan worden genomen, is het mogelijk geworden om in opdracht filmpjes te maken.
